# Project1 v.9 150 millones v.2

Schedule from MS Project, 2023-06-01 to 2027-12-30, costs in $.
Inter-American Development Bank

## Calendars

- Standard: Mon-Fri 08:00-12:00, 13:00-17:00; Sat-Sun off.

## Schedule

| ID | WBS | Task | Duration | Start | Finish | Total slack | Constraint | Cost | Baseline cost | Programa institucional Mineduc |
| --- | --- | --- | --- | --- | --- | --- | --- | --- | --- | --- |
| 1 | 1 | **PROGRAMA DE APOYO A LA EXPANSIÓN DE LA EDUCACIÓN MEDIA (GU-L1184)** | 1196d | 2023-06-01 | 2027-12-30 | 0d |  | 100,000,000 |  |  |
| 2 | 1.1 | **Mejora de la cobertura y eficiencia interna educativa en el nivel medio** | 1164d | 2023-06-01 | 2027-11-16 | 32d |  | 96,000,000 |  |  |
| 3 | 1.1.1 | **Ampliación de la oferta educativa para el nivel de educación media, ciclo básico y ciclo diversificado** | 877d | 2023-06-01 | 2026-10-09 | 319d |  | 22,500,000 |  |  |
| 4 | 1.1.1.1 | **Adquisicion de 500 modulos educativos prefabricados** | 462d | 2023-06-01 | 2025-03-07 | 734d |  | 16,500,000 |  |  |
| 5 | 1.1.1.1.1 | Año 2. 250 modulos educativos | 200d | 2023-06-01 | 2024-03-06 | 996d | start no earlier than 2023-06-01 | 8,250,000 | 10,000,000 | 11.01.000.004 |
| 6 | 1.1.1.1.2 | Año 3. 250 modulos educativos | 200d | 2024-06-03 | 2025-03-07 | 734d | start no earlier than 2024-06-03 | 8,250,000 | 20,000,000 | 11.01.000.004 |
| 7 | 1.1.1.2 | **Adquisicion de mobiliario escolar para 500 modulos educativos prefabricados** | 335d | 2023-10-02 | 2025-01-10 | 774d |  | 1,000,000 |  |  |
| 8 | 1.1.1.2.1 | Año 3. mobiliario escolar para 250 modulos educativos prefabricados | 160d | 2023-10-02 | 2024-05-10 | 949d | start no earlier than 2023-10-02 | 500,000 |  | 11.01.000.004 |
| 9 | 1.1.1.2.2 | Año 3. mobiliario escolar para 250 modulos educativos prefabricados | 160d | 2024-06-03 | 2025-01-10 | 774d | start no earlier than 2024-06-03 | 500,000 |  | 11.01.000.004 |
| 10 | 1.1.1.3 | **Adquisición de mobiliario escolar para 2500 aulas** | 839d | 2023-07-25 | 2026-10-09 | 319d |  | 5,000,000 |  |  |
| 11 | 1.1.1.3.1 | Año 2. mobiliario escolar para 500 aulas | 160d | 2023-07-25 | 2024-03-04 | 998d | finish no earlier than 2024-03-04 | 1,000,000 |  |  |
| 12 | 1.1.1.3.2 | Año 3. mobiliario escolar para 1000 aulas | 160d | 2024-07-23 | 2025-03-03 | 738d | finish no earlier than 2025-03-03 | 2,000,000 |  |  |
| 13 | 1.1.1.3.3 | Año 4. mobiliario escolar para 1000 aulas | 160d | 2026-03-02 | 2026-10-09 | 319d | start no earlier than 2026-03-02 | 2,000,000 |  | 11.01.000.004 |
| 14 | 1.1.2 | **Remozamiento de aulas deterioradas en el nivel de educación media, ciclo básico y ciclo diversificado** | 710d | 2024-03-04 | 2026-11-20 | 289d |  | 31,500,000 |  |  |
| 15 | 1.1.2.1 | **Reparación de 3150 escuelas a través de OPF** | 710d | 2024-03-04 | 2026-11-20 | 289d |  | 31,500,000 |  |  |
| 16 | 1.1.2.1.1 | Año 1. 1000 escuelas | 183d | 2024-03-04 | 2024-11-13 | 816d | start no earlier than 2024-03-04 | 10,000,000 |  |  |
| 17 | 1.1.2.1.2 | Año 2. 1000 escuelas | 189d | 2025-03-10 | 2025-11-27 | 545d | start no earlier than 2025-03-10 | 10,000,000 |  |  |
| 18 | 1.1.2.1.3 | Año 3. 1150 escuelas | 185d | 2026-03-09 | 2026-11-20 | 289d | start no earlier than 2026-03-09 | 11,500,000 |  |  |
| 19 | 1.1.3 | **Dotación de materiales educativos y dispositivos digitales a los estudiantes y docentes** | 510d | 2025-01-06 | 2026-12-18 | 269d |  | 29,000,000 |  |  |
| 20 | 1.1.3.1 | **Adquisicion de 2.3 millones libros de texto** | 425d | 2025-05-05 | 2026-12-18 | 269d |  | 6,000,000 |  |  |
| 21 | 1.1.3.1.1 | Adquisicion de 1.15 millones de libros de texto | 160d | 2025-05-05 | 2025-12-12 | 534d | start no earlier than 2025-05-05 | 3,000,000 |  |  |
| 22 | 1.1.3.1.2 | Adquisicion de 1,15 millones de libros de texto | 160d | 2026-05-11 | 2026-12-18 | 269d | start no earlier than 2026-05-11 | 3,000,000 |  | 21.00.000.001 |
| 23 | 1.1.3.2 | **Adquisición de tecnología escolar para 3,800 aulas** | 510d | 2025-01-06 | 2026-12-18 | 269d |  | 23,000,000 |  |  |
| 24 | 1.1.3.2.1 | Adquisición de tecnología escolar para 1,900 aulas | 250d | 2025-01-06 | 2025-12-19 | 529d | start no earlier than 2025-01-06 | 11,500,000 |  | 11.01.000.003 |
| 25 | 1.1.3.2.2 | Adquisición de tecnología escolar para 1,900 aulas | 250d | 2026-01-05 | 2026-12-18 | 269d | start no earlier than 2026-01-05 | 11,500,000 |  | 12.01.000.004 |

Notes:
- 4: Ampliar la cobertura en un 10% en preprimaria.

| ID | WBS | Task | Duration | Start | Finish | Predecessors | Total slack | Free slack | Constraint | Cost |
| --- | --- | --- | --- | --- | --- | --- | --- | --- | --- | --- |
| 26 | 1.1.4 | **Fortalecimiento de las competencias de los docentes** | 1054d | 2023-11-02 | 2027-11-16 |  | 32d |  |  | 13,000,000 |
| 27 | 1.1.4.1 | **Capacitación de maestros PADEP (Mínimo 5700 docentes)** | 1054d | 2023-11-02 | 2027-11-16 |  | 32d |  |  | 13,000,000 |
| 28 | 1.1.4.1.1 | Año 1 (1000) | 15d | 2023-11-02 | 2023-11-22 |  | 1071d |  | start no earlier than 2023-11-02 | 872,483 |
| 29 | 1.1.4.1.2 | Año 2 (1000+1200=2,200) | 15d | 2024-10-24 | 2024-11-13 |  | 816d |  | start no earlier than 2024-10-24 | 1,919,463 |
| 30 | 1.1.4.1.3 | Año 3 (1000+1200+1300=3,500) | 15d | 2025-10-30 | 2025-11-19 |  | 551d |  | start no earlier than 2025-10-30 | 3,053,691 |
| 31 | 1.1.4.1.4 | Año 4 (1200+1,300+2200=4700) | 15d | 2026-10-29 | 2026-11-18 |  | 291d |  | start no earlier than 2026-10-29 | 4,100,671 |
| 32 | 1.1.4.1.5 | Año 5 (1,300+2200=3500) | 15d | 2027-10-27 | 2027-11-16 |  | 32d |  | start no earlier than 2027-10-27 | 3,053,692 |
| 33 | 1.2 | **Administración, Supervisión y Evaluación** | 1196d | 2023-06-01 | 2027-12-30 |  | 0d |  |  | 4,000,000 |
| 34 | 1.2.1 | **Administración, supervisión y evaluación** | 1196d | 2023-06-01 | 2027-12-30 |  | 0d |  |  | 4,000,000 |
| 35 | 1.2.1.1 | Año 1 | 150d | 2023-06-01 | 2023-12-27 |  | 1046d |  | start no earlier than 2023-06-01 | 500,000 |
| 36 | 1.2.1.2 | Año 2 | 259d | 2024-01-01 | 2024-12-26 |  | 785d |  | start no earlier than 2024-01-01 | 1,000,000 |
| 37 | 1.2.1.3 | Año 3 | 260d | 2025-01-01 | 2025-12-30 |  | 262d | 1d | start no earlier than 2025-01-01 | 1,200,000 |
| 38 | 1.2.1.4 | Año 4 | 260d | 2026-01-01 | 2026-12-30 | 37 | 261d |  | start no earlier than 2026-01-01 | 900,000 |
| 39 | 1.2.1.5 | Año 5 | 260d | 2027-01-01 | 2027-12-30 |  | 0d |  | start no earlier than 2027-01-01 | 400,000 |
